# 3GPP_Release-2000

Schedule from MS Project, 2000-01-03 to 2008-03-10, A marks actual dates.

## Calendars

- Standard: Mon-Fri 08:00-12:00, 13:00-17:00; Sat-Sun off.

## Resources

| Resource |
| --- |
| NP |
| N1 |
| N2 |
| N3 |
| N4 |
| N5 |
| TP |
| T1 |
| T2 |
| T3 |
| RP |
| R1 |
| R2 |
| R3 |
| R4 |
| SP |
| S1 |
| S2 |
| S3 |
| S4 |
| S5 |
| PCG |
| GP |
| No |
| CN4 |
| ? |
| WG G2 |
| G2 |
| G1 |
| G4 |
| G3 |
| All |
| Generic |
| MLST |
| G5 |
| S3, G2 |
| WG T2 |
| GP,G1 |
| G4,G5 |
| OMA |
| GP-G2 |
| Yes |
| GP; |
| NGN |
| WG1 |
| WG2 |
| WG3 |
| WG5 |
| WG4 |
| WG6 |
| WG7 |
| WG8 |
| WG |
| X |
| TISPAN |

## Schedule

| ID | WBS | Task | Duration | Start | Finish | Complete | Remaining | Baseline start | Baseline finish | Baseline duration | Total slack | Constraint | Resources | Work | Actual work | Text6 | Text9 | Text4 | Text5 | Text13 | Text14 | Text15 |
| --- | --- | --- | --- | --- | --- | --- | --- | --- | --- | --- | --- | --- | --- | --- | --- | --- | --- | --- | --- | --- | --- | --- |
| 1 | 1 | TISPAN Work Plan Rel-2 for 3GPP, without OSA | 520d? | 2003-09-22 | 2005-09-16 |  |  | 2003-09-22 | 2005-09-16 | 520d? | 646d | finish no earlier than 2005-09-16 |  |  |  |  |  |  |  |  |  |  |
| 2 | 1 | VERSION 2007 June 4th | 520d | 2003-09-22 | 2005-09-16 |  |  | 2003-09-22 | 2005-09-16 | 520d | 646d | finish no earlier than 2005-09-16 |  |  |  | Rel | 2044 |  |  |  |  |  |
| 3 | 2 | In Green: to be partly or completely transferred to 3GPP | 520d | 2003-09-22 | 2005-09-16 |  |  | 2003-09-22 | 2005-09-16 | 520d | 646d | finish no earlier than 2005-09-16 |  |  |  |  | 1462 |  |  |  |  |  |
| 4 | 4 | In Red: to remain in TISPAN | 520d | 2003-09-22 | 2005-09-16 |  |  | 2003-09-22 | 2005-09-16 | 520d | 646d | finish no earlier than 2005-09-16 |  |  |  | Rel |  |  |  |  |  |  |
| 5 | 5 | In black: to be clarified | 1d? | 2000-01-03 | 2000-01-03 |  |  |  |  |  | 2135d |  |  |  |  |  |  |  |  |  |  |  |
| 7 | 6 | **Rel-2 Overall Description** | 443d? | 2006-01-01 A | 2007-09-12 | 60% | 177.56d? | 2006-01-01 | 2007-09-25 | 451.4d? | 128d |  |  | 8968h | 5373.6h |  |  |  |  |  |  |  |
| 8 | 6.1 | NGN Release 2 definition | 320d? | 2006-05-09 A | 2007-07-30 | 80% | 64d? | 2006-05-09 | 2007-07-30 | 320d? | 160d | finish no earlier than 2007-07-30 | TISPAN | 2560h | 2048h |  |  | Knight Dick | dick.rr.knight@bt.com | 180 002 | 0.4.0 | 6-Stable |
| 9 | 6.2 | Service Requirements and Network Capabilities for Release 2 | 440d? | 2006-01-01 A | 2007-09-07 | 51% | 213.5d? | 2006-01-01 | 2007-02-27 | 302d? | 131d | finish no earlier than 2007-09-07 | WG1 | 3520h | 1812h |  |  | Kotar Peter | P.Kotar@alcatel-lucent.de | 181 005 or 181 013 ? | 2.0.5 | 6-Stable |
| 10 | 6.3 | NGN Functional Architecture Release 2: Overall architecture | 187d? | 2006-09-12 A | 2007-05-30 | 50% | 93.5d? | 2006-09-04 | 2007-05-30 | 193d? | 203d | start no earlier than 2006-09-12 | WG2 | 1496h | 748h |  |  | Chatras Bruno | bruno.chatras@orange-ftgroup.com | 282 001 | 0.0.8 | 6-Stable |
| 11 | 6.4 | NGN Terminology | 174d? | 2007-01-12 A | 2007-09-12 | 55% | 78.3d? | 2007-01-01 | 2007-09-25 | 191.4d? | 128d | finish no earlier than 2007-08-30 | TISPAN | 1392h | 765.6h |  |  | Pulverer Klaus | klaus.pulverer@nsn.com | 180 000 | 2.0.2 | 6-Stable |
| 12 | 7 | **IMS Evolution and Supplementary Services** | 874d? | 2004-11-03 A | 2008-03-10 | 66% | 299.42d? | 2004-11-03 | 2007-07-30 | 714d? | 0d |  |  | 46744h | 30730.4h |  |  |  |  |  |  |  |
| 13 | 7.1 | Diameter based protocol for the interfaces between CSCF and UPSF /SLF [3GPP TS 29.228 V7.4.0 and 3GPP TS 29.229 V7.4.0 modified] | 150d? | 2007-03-30 A | 2007-10-25 | 20% | 120d? |  |  |  | 97d | finish no earlier than 2007-10-25 | WG3 | 1200h | 240h |  |  | Barcariol Daniela | daniela.barcariol@telecomitalia.it | 183 033 | 2.0.1 | 6-Stable |
| 14 | 7.2 | IMS Call Control Protocol based on SIP and SDP Stage 3 [3GPP TS 24.229, modified] | 214d? | 2007-05-16 | 2008-03-10 |  |  |  |  |  | 0d | start no earlier than 2007-05-16 | WG3 | 1712h |  |  |  | Barcariol Daniela | daniela.barcariol@telecomitalia.it | 283 003 |  | 0-New |
| 15 | 7.3 | **Advice of Charge (AoC)** | 623d? | 2004-11-03 A | 2007-03-23 A | 100% |  | 2004-11-03 | 2007-03-30 | 628d? |  |  |  | 4984h | 4984h |  |  |  |  |  |  |  |
| 16 | 7.3.1 | AOC Stage 3 | 623d? | 2004-11-03 A | 2007-03-23 A | 100% |  | 2004-11-03 | 2007-03-30 | 628d? |  | finish no earlier than 2007-03-23 | WG3 | 4984h | 4984h |  |  | Huelsemann Martin | Martin.Huelsemann@t-com.net | 183 047 | 2.1.1 | 12 |
| 17 | 7.4 | **Call Completion on Busy Subscriber (CCBS), Call Completion No Reply (CCNR)** | 777d? | 2004-11-03 A | 2007-10-25 | 65% | 274.6d? | 2004-11-03 | 2007-03-30 | 628d? | 97d |  |  | 6216h | 4019.2h |  |  |  |  |  |  |  |
| 18 | 7.4.1 | CCBS CCNR Stage 3 | 777d? | 2004-11-03 A | 2007-10-25 | 65% | 274.6d? | 2004-11-03 | 2007-03-30 | 628d? | 97d | finish no earlier than 2007-10-25 | WG3 | 6216h | 4019.2h |  |  | Huelsemann Martin | Martin.Huelsemann@t-com.net | 183 042 | 0.0.17 | 6-Stable |
| 19 | 7.5 | **Call Waiting (CW)** | 777d? | 2004-11-03 A | 2007-10-25 | 65% | 274.6d? | 2004-11-03 | 2007-03-30 | 628d? | 97d |  |  | 6216h | 4019.2h |  |  |  |  |  |  |  |
| 20 | 7.5.1 | CW Stage 3 | 777d? | 2004-11-03 A | 2007-10-25 | 65% | 274.6d? | 2004-11-03 | 2007-03-30 | 628d? | 97d | finish no earlier than 2007-10-25 | WG3 | 6216h | 4019.2h |  |  | Huelsemann Martin | Martin.Huelsemann@t-com.net | 183 015 | 0.0.23 | 6-Stable |
| 21 | 7.6 | **Communication Diversion (CDIV)** | 261d? | 2006-06-16 A | 2007-06-15 | 43% | 148.07d? | 2006-06-16 | 2007-03-30 | 206d? | 191d |  |  | 4160h | 1800h |  |  |  |  |  |  |  |
| 22 | 7.6.1 | CDIV Stage 3 (Protocol specification) | 250d? | 2006-06-16 A | 2007-05-31 | 90% | 25d? | 2006-06-16 | 2007-03-30 | 206d? | 202d | finish no earlier than 2007-05-31 | WG3 | 2000h | 1800h |  |  | Jesske Roland | r.jesske@t-com.net | 183 004 | 2.0.5 | 7-WGapp |
| 23 | 7.6.2 | **CDIV Testing** | 135d? | 2006-12-11 | 2007-06-15 |  |  |  |  |  | 191d |  |  | 2160h |  |  |  | Gerhard Ott | gerhard.ott@t-com.net |  |  |  |
| 24 | 7.6.2.1 | Part 1 - PICS | 135d? | 2006-12-11 | 2007-06-15 |  |  |  |  |  | 191d | finish no earlier than 2007-06-15 | WG6 | 1080h |  |  |  | Gerhard Ott | gerhard.ott@t-com.net |  |  |  |
| 25 | 7.6.2.2 | Part 2: Test Suite Structure and Test Purposes | 135d? | 2006-12-11 | 2007-06-15 |  |  |  |  |  | 191d | start no earlier than 2006-12-11 | WG6 | 1080h |  |  |  | Gerhard Ott | gerhard.ott@t-com.net |  |  |  |

| ID | WBS | Task | Type | Duration | Start | Finish | Complete | Remaining | Baseline start | Baseline finish | Baseline duration | Total slack | Constraint | Resources | Work | Actual work | Text4 | Text5 | Text13 | Text14 | Text15 |
| --- | --- | --- | --- | --- | --- | --- | --- | --- | --- | --- | --- | --- | --- | --- | --- | --- | --- | --- | --- | --- | --- |
| 26 | 7.7 | **Conference (CONF)** |  | 324d? | 2006-07-30 A | 2007-10-25 | 32% | 220d? | 2006-07-30 | 2007-01-28 | 130d? | 97d |  |  | 2592h | 832h |  |  |  |  |  |
| 27 | 7.7.1 | CONF Stage 3 (Protocol specification) |  | 324d? | 2006-07-30 A | 2007-10-25 | 32% | 220d? | 2006-07-30 | 2007-01-28 | 130d? | 97d | finish no earlier than 2007-10-25 | WG3 | 2592h | 832h | Chou(Zhou) Justin(Qing) | zhouqing@huawei.com | 183 005 | 2.1.0 | 6-Stable |
| 28 | 7.8 | **Malicious Communication Identification (MCID)** |  | 271d? | 2006-06-16 A | 2007-06-30 | 90% | 27.1d? | 2006-06-16 | 2007-03-30 | 206d? | 181d |  |  | 2168h | 1951.2h |  |  |  |  |  |
| 29 | 7.8.1 | MCID Stage 3 (Protocol Specification) |  | 271d? | 2006-06-16 A | 2007-06-30 | 90% | 27.1d? | 2006-06-16 | 2007-03-30 | 206d? | 181d | finish no earlier than 2007-06-30 | WG3 | 2168h | 1951.2h | Jesske Roland | r.jesske@t-com.net | 183 016 | 2.4.0 | 7-WGapp |
| 30 | 7.9 | **Terminating Identification Presentation (TIP) and Terminating Identification Restriction (TIR)** |  | 271d? | 2006-06-16 A | 2007-06-30 | 90% | 27.1d? | 2006-06-16 | 2007-03-30 | 206d? | 181d |  |  | 2168h | 1951.2h |  |  |  |  |  |
| 31 | 7.9.1 | TIP and TIR Stage 3 (Protocol specification) |  | 271d? | 2006-06-16 A | 2007-06-30 | 90% | 27.1d? | 2006-06-16 | 2007-03-30 | 206d? | 181d | finish no earlier than 2007-06-30 | WG3 | 2168h | 1951.2h | Van der Gaast Sietse | gaast@ALCATEL-LUCENT.COM | 183 008 | 2.4.0 | 7-WGapp |
| 32 | 7.10 | STOPPED - Requirements for a NGN Session Control Protocol and analysis of the IMS SIP profile meets these requirements |  | 88d? | 2006-10-30 A | 2007-02-28 | 20% | 70.4d? | 2006-10-30 | 2007-02-28 | 88d? | 268d | finish no earlier than 2007-02-28 | WG2 | 704h | 140.8h | Garcin Sébastien | sebastien.garcin@ORANGE-FTGROUP.COM | EG 282 016 | 0.0.1 | 2-1stDraft |
| 33 | 7.11 | Session Transfer |  | 290d? | 2006-09-05 A | 2007-10-25 | 10% | 261.8d? | 2006-09-15 | 2007-03-30 | 141d? | 97d | finish no earlier than 2007-10-25 | WG3 | 2320h | 225.6h | Huelsemann Martin | Martin.Huelsemann@t-com.net | 183 029 | 2.1.0 | 6-Stable |
| 34 | 7.12 | **SMS over NGN IMS** |  | 411d? | 2006-01-01 A | 2007-07-30 | 71% | 117.38d? | 2006-01-01 | 2007-07-30 | 411d? | 160d |  |  | 5496h | 3926.4h |  |  |  |  |  |
| 35 | 7.12.1 | Overview of Messaging Services |  | 184d? | 2006-01-01 A | 2006-09-14 | 90% | 18.4d? | 2006-01-01 | 2006-09-14 | 184d? | 387d | start no earlier than 2006-01-01 | WG1 | 1472h | 1324.8h |  |  | TR 181 007 | NGN-R2 | Draft receipt by ETSI Secretariat |
| 36 | 7.12.2 | Overview of Messaging Services |  | 139d? | 2006-04-07 A | 2006-10-18 A | 100% |  | 2006-04-07 | 2006-10-18 | 139d? |  | start no earlier than 2006-04-07 | WG1 | 1112h | 1112h | Julien Christian | christian.julien@etsi.org | 181 007 | 2.1.1 | 12 |
| 37 | 7.12.3 | SMS over IMS Stage 2 |  | 162d? | 2006-09-15 A | 2007-04-30 | 90% | 16.2d? | 2006-09-15 | 2007-04-30 | 162d? | 225d | finish no earlier than 2007-04-30 | WG2 | 1296h | 1166.4h | Westman Ilkka | ilkka.westman@nsn.com | 182 021 | 0.0.4 | 6-Stable |
| 38 | 7.12.4 | SMS over IMS Stage 3 |  | 202d? | 2006-10-20 A | 2007-07-30 | 20% | 161.6d? | 2006-10-20 | 2007-07-30 | 202d? | 160d | finish no earlier than 2007-07-30 | WG3 | 1616h | 323.2h | Molnar Attila | attila.molnar@nsn.com | 183 051 | 2.0.0 | 6-Stable |
| 39 | 7.13 | **Direct Communication Service** |  | 366d? | 2005-07-15 A | 2006-12-08 | 98% | 8.99d? | 2005-07-15 | 2006-12-08 | 366d? | 326d |  |  | 6808h | 6640.8h |  |  |  |  |  |
| 40 | 7.13.1 | DC Stage 1: Service Description (Endorsement of OMA-ERELD-PoC-V1: NGN DC stage 1) |  | 209d? | 2006-01-01 A | 2006-10-19 | 90% | 20.9d? | 2006-01-01 | 2006-10-19 | 209d? | 362d | start no earlier than 2006-01-01 | WG1 | 1672h | 1504.8h |  |  | TS 181 006 | NGN-R2 | Draft receipt by ETSI Secretariat |
| 41 | 7.13.2 | DC Stage 1(Endorsement of OMA-ERELD-PoC-V1) |  | 150d? | 2006-04-07 A | 2006-11-02 A | 100% |  | 2006-04-07 | 2006-11-02 | 150d? |  | start no earlier than 2006-04-07 | WG1 | 1200h | 1200h | Jesske Roland | r.jesske@t-com.net | 181 006 | 2.1.1 | 12 |
| 42 | 7.13.3 | DC Stage 2: Architecture of Direct Communication (ADC) |  | 126d? | 2006-06-16 A | 2006-12-08 A | 100% |  | 2006-06-16 | 2006-12-08 | 126d? |  | finish no earlier than 2006-12-08 | WG2 | 1008h | 1008h | Jesske Roland | r.jesske@t-com.net | 182 017 | 1.1.1 | 12 |
| 43 | 7.13.4 | DC Stage 3: Protocol Specification |  | 366d? | 2005-07-15 A | 2006-12-08 A | 100% |  | 2005-07-15 | 2006-12-08 | 366d? |  | finish no earlier than 2006-12-08 | WG3 | 2928h | 2928h | Holm Jan | Jan.Holm@ericsson.com | 183 045 | 2.1.1 | 12 |
| 44 | 8 | **PSTN/ISDN Simulation Subsystem** |  | 225d? | 2006-12-15 A | 2007-10-25 | 21% | 177.78d? | 2006-12-30 | 2007-03-30 | 65d? | 97d |  |  | 5232h | 1098h |  |  |  |  |  |
| 45 | 8.1 | STOPPED - PSS: Protocol specification Subaddressing (SUB) | milestone | 0d? | 2007-05-31 | 2007-05-31 |  |  | 2006-12-30 | 2007-03-30 | 65d? | 202d | start no earlier than 2007-05-31 | WG3 |  |  | Jesske Roland | r.jesske@t-com.net |  | 0.0.1 | TBadoptionofWI |
| 46 | 8.2 | PSS: Protocol specification Closed User Group (CUG) |  | 214d? | 2006-12-15 A | 2007-10-25 | 20% | 171.2d? | 2006-12-30 | 2007-03-30 | 65d? | 97d | finish no earlier than 2007-10-25 | WG3 | 1712h | 342.4h | Jesske Roland | r.jesske@t-com.net | 183 054 | 0.0.4 | 6-Stable |
| 47 | 8.3 | PSS: Protocol specification User-to-user signalling 1 (UUS1) |  | 214d? | 2006-12-15 A | 2007-10-25 | 2% | 210.75d? | 2006-12-30 | 2007-03-30 | 65d? | 97d | finish no earlier than 2007-10-25 | WG3 | 1712h | 26h | Jesske Roland | r.jesske@t-com.net | 183 055 | 0.0.1 | 6-Stable |
| 48 | 8.4 | Multimedia Telephony with NGN simulation services |  | 141d? | 2006-12-15 A | 2007-06-29 | 65% | 49.8d? | 2006-12-30 | 2007-10-30 | 217d? | 181d | finish no earlier than 2007-06-29 | WG1 | 1128h | 729.6h | Lottin Philippe | philippe.lottin@orange-ftgroup.com | 181 002 | 2.2.0 | 6-Stable |
| 49 | 8.5 | Multimedia Telephony with PSTN/ISDN simulation services; Stage 3 |  | 85d? | 2007-06-29 | 2007-10-25 |  |  |  |  |  | 97d | finish no earlier than 2007-10-25 | WG3 | 680h |  | Pareglio Barbara | barbara.pareglio@ericsson.com |  |  | 0-New |

Notes:
- 34: Name changed to remove MMS

| ID | WBS | Task | Duration | Start | Finish | Complete | Remaining | Baseline start | Baseline finish | Baseline duration | Total slack | Constraint | Resources | Work | Actual work | Text4 | Text5 | Text13 | Text14 | Text15 |
| --- | --- | --- | --- | --- | --- | --- | --- | --- | --- | --- | --- | --- | --- | --- | --- | --- | --- | --- | --- | --- |
| 50 | 9 | **IP Television (IPTV)** | 401d? | 2006-06-01 A | 2007-12-13 | 45% | 219.78d? | 2006-06-01 | 2007-11-30 | 392d? | 62d |  |  | 10928h | 4938.48h |  |  |  |  |  |
| 51 | 9.1 | Requirements for network capabilities to support IPTV services: IPTV requirements | 181d? | 2006-10-20 A | 2007-06-29 | 87% | 23.59d? | 2006-10-20 | 2007-05-30 | 159d? | 181d | finish no earlier than 2007-06-29 | WG1 | 1448h | 1259.28h | Mainwaring Keith | kmainwar@cisco.com | 181 014 | 0.0.12 | 6-Stable |
| 52 | 9.2 | Requirements to integrate NGN services and IPTV | 250d? | 2006-07-17 A | 2007-06-29 | 64% | 90.4d? | 2006-07-17 | 2007-05-30 | 228d? | 181d | finish no earlier than 2007-06-29 | WG1 | 2000h | 1276.8h | Martti Jyrki | jyrki.martti@nsn.com | 181 016 | 0.0.7 | 6-Stable |
| 53 | 9.3 | IPTV Architecture: Dedicated subsystem for IPTV functions: IPTV in NGN | 240d? | 2006-12-30 A | 2007-11-30 | 50% | 120d? | 2006-12-30 | 2007-11-30 | 240d? | 71d | finish no earlier than 2007-11-30 | WG2 | 1920h | 960h | Kisel Andrey | Andrey.Kisel@ALCATEL-LUCENT.CO.UK | 182 028 | 0.0.4 | 6-Stable |
| 54 | 9.4 | IPTV Architecture: IPTV functions supported by the IMS subsystem: IPTV IMS-based | 219d? | 2006-10-30 A | 2007-08-30 | 60% | 87.6d? | 2006-10-30 | 2007-08-30 | 219d? | 137d | finish no earlier than 2007-08-30 | WG2 | 1752h | 1051.2h | Bjarlestam Andreas | andreas.bjarlestam@ericsson.com | 182 027 | 0.0.2 | 2-1st Draft |
| 55 | 9.5 | IPTV Architecture: Common architectural aspects | 326d? | 2006-06-01 A | 2007-08-30 | 15% | 277.1d? | 2006-06-01 | 2006-12-29 | 152d? | 137d | finish no earlier than 2007-08-30 | WG2 | 2608h | 391.2h | Brockners Frank | fbrockne@cisco.com |  | 0.0.4 | 5-Discussion |
| 56 | 9.6 | MS-based IPTV stage 3 specification | 150d? | 2007-05-18 | 2007-12-13 |  |  |  |  |  | 62d | start no earlier than 2007-05-18 | WG3 | 1200h |  | Yan Jun | yan_jun@huawei.com |  |  | 0-New |
| 57 | 10 | **Voice call continuity for Fixed IMS (VCC)** | 138d? | 2007-03-08 A | 2007-09-17 | 60% | 55.2d? |  |  |  | 125d |  |  | 1104h | 662.4h |  |  |  |  |  |
| 58 | 10.1 | VCC Stage 2 | 138d? | 2007-03-08 A | 2007-09-17 | 60% | 55.2d? |  |  |  | 125d | finish no earlier than 2007-08-30 | WG2 | 1104h | 662.4h | Ascolese Antonio | antonio.ascolese@telecomitalia.it |  | 0.1.0 | 6-Stable |
| 59 | 11 | **Fixed Mobile Convergence (FMC)** | 271d? | 2006-06-16 A | 2007-06-29 | 57% | 116.5d? | 2006-06-16 | 2007-03-30 | 206d? | 181d |  |  | 2168h | 1236h |  |  |  |  |  |
| 60 | 11.1 | FMC Requirements analysis | 271d? | 2006-06-16 A | 2007-06-29 | 57% | 116.5d? | 2006-06-16 | 2007-03-30 | 206d? | 181d | finish no earlier than 2007-06-29 | WG1 | 2168h | 1236h | Khan Asan | asan.khan@sprint.com | 181 011 | 0.0.13 | 6-Stable |
| 61 | 12 | **User data** | 75d? | 2006-11-30 A | 2007-03-14 | 80% | 15d? | 2006-11-30 | 2007-03-14 | 75d? | 258d |  |  | 600h | 480h |  |  |  |  |  |
| 62 | 12.1 | Incorporating Universal Communications Identifier (UCI) support into the specification of Next Generation Networks: NGN UCI | 75d? | 2006-11-30 A | 2007-03-14 | 80% | 15d? | 2006-11-30 | 2007-03-14 | 75d? | 258d | finish no earlier than 2006-11-30 | WG4 | 600h | 480h | Pluke Michael | Mike.Pluke@CASTLE-CONSULT.COM |  | 0.0.2 | 6-Stable |
| 63 | 13 | **Corporate Network** | 253d? | 2006-07-12 A | 2007-06-29 | 63% | 94.58d? | 2006-07-12 | 2007-05-30 | 231d? | 181d |  |  | 4400h | 2755.2h |  |  |  |  |  |
| 64 | 13.1 | Stage 1: Business Communication and Business Trunking Requirements | 253d? | 2006-07-12 A | 2007-06-29 | 64% | 91.3d? | 2006-07-12 | 2007-05-30 | 231d? | 181d | finish no earlier than 2007-06-29 | WG1 | 2024h | 1293.6h | Van Elburg Hans Erik | HansErik.van.Elburg@ericsson.com | 181 019 | 0.8.1 | 6-Stable |
| 65 | 13.2 | With ECMA: Core and Enterprise NGN Interaction Scenarios and Architectural Requirements | 123d? | 2006-09-15 A | 2007-03-06 | 60% | 49.2d? | 2006-09-11 | 2007-02-28 | 123d? | 264d | finish no earlier than 2007-02-28 | WG2 | 984h | 590.4h | Drage Keith | drage@alcatel-lucent.com | 182 023 | 0.2.1 | 6-Stable |
| 66 | 13.3 | Hosted Enterprise Services: Architecture and functional description | 80d? | 2006-10-11 A | 2007-01-30 | 95% | 4d? | 2006-10-11 | 2007-01-30 | 80d? | 289d | finish no earlier than 2007-01-30 | WG2 | 640h | 608h | Chatras Bruno | bruno.chatras@orange-ftgroup.com | 182 024 | 0.0.9 | 6-Stable |
| 67 | 13.4 | Stage 2: Business Trunking: Architecture and functional description | 94d? | 2006-10-20 A | 2007-02-28 | 35% | 61.1d? | 2006-10-20 | 2007-02-28 | 94d? | 268d | finish no earlier than 2007-02-28 | WG2 | 752h | 263.2h | Drage Keith | drage@alcatel-lucent.com | 182 025 | 0.1.0 | 2-1st Draft |
| 68 | 14 | **Customer ("Home") networks connected to TISPAN NGN (HN)** | 400d? | 2006-04-07 A | 2007-10-18 | 74% | 105.31d? | 2006-04-07 | 2007-07-13 | 331d? | 102d |  |  | 7576h | 5253.77h |  |  |  |  |  |
| 69 | 14.1 | HN Requirements and capabilities | 1d? | 2007-07-13 A | 2007-07-13 | 12% | 0.88d? | 2007-07-13 | 2007-07-13 | 1d? | 171d | start no earlier than 2007-07-13 | WG3 | 8h | 0.97h | Erbes Milan | milan_e@yahoo.com |  |  | 1-Start |
| 70 | 14.2 | HN Services requirements and capabilities analysis for Customer Premises Network (CPN) | 299d? | 2006-04-07 A | 2007-05-30 | 90% | 29.9d? |  |  |  | 203d | finish no earlier than 2007-05-30 | WG1 | 2392h | 2152.8h | Erbes Milan | milan.erbes@ds2.es | 181 012 | 0.0.5 | 6-Stable |
| 71 | 14.3 | **Customer Network** | 64d? | 2007-02-20 A | 2007-05-18 A | 100% |  |  |  |  |  |  |  | 1024h | 1024h |  |  |  |  |  |
| 72 | 14.3.1 | Services requirements and capabilities for customer networks | 64d? | 2007-02-20 A | 2007-05-18 A | 100% |  |  |  |  |  | finish no earlier than 2007-05-18 | WG5 | 512h | 512h | Milan ERBES | milan_e@yahoo.com |  |  |  |
| 73 | 14.3.2 | Analysis of the customer network architectues | 64d? | 2007-02-20 A | 2007-05-18 A | 100% |  |  |  |  |  | finish no earlier than 2007-05-18 | WG5 | 512h | 512h | Radu Suciu | radu.suciu@alcatel.lucent.be |  |  |  |

Notes:
- 51: Might be 80% complete
- 68: formerly known as Home gateway and Customer premises equipment

| ID | WBS | Task | Type | Duration | Start | Finish | Complete | Remaining | Baseline start | Baseline finish | Baseline duration | Total slack | Constraint | Resources | Work | Actual work | Text4 | Text5 | Text14 | Text15 | Text13 |
| --- | --- | --- | --- | --- | --- | --- | --- | --- | --- | --- | --- | --- | --- | --- | --- | --- | --- | --- | --- | --- | --- |
| 74 | 14.4 | **Customer Network Gateway (CNG)** |  | 173d? | 2007-02-20 A | 2007-10-18 | 50% | 86.5d? |  |  |  | 102d |  | WG5 | 2768h | 1384h | Bastien LAMER | bastien.lamer@orange-ftgroup.com |  |  |  |
| 75 | 14.4.1 | CNG architecture and interfaces |  | 173d? | 2007-02-20 A | 2007-10-18 | 50% | 86.5d? |  |  |  | 102d | finish no earlier than 2007-10-18 | WG5 | 1384h | 692h | Bastien LAMER | bastien.lamer@orange-ftgroup.com |  |  |  |
| 76 | 14.5 | **Customer Devices (CD)** |  | 173d? | 2007-02-20 A | 2007-10-18 | 50% | 86.5d? |  |  |  | 102d |  |  | 1384h | 692h |  |  |  |  |  |
| 77 | 14.5.1 | Customer devices architecture and interfaces |  | 173d? | 2007-02-20 A | 2007-10-18 | 50% | 86.5d? |  |  |  | 102d | finish no earlier than 2007-10-18 | WG5 | 1384h | 692h | Fabrizio VERROCA | Fabrizio.verroca@telecomitalia.it |  |  |  |
| 78 | 15 | **Interconnection and Numbering Rel-2** |  | 852d? | 2004-02-25 A | 2007-05-31 | 73% | 228.53d? | 2004-02-25 | 2007-04-30 | 829d? | 202d |  |  | 10224h | 7481.6h |  |  |  |  |  |
| 79 | 15.1 | STOPPED - ENUM implementation scenarios: ENUM Scenarios | milestone | 0d? | 2006-10-30 | 2006-10-30 |  |  | 2005-04-30 | 2006-10-30 | 391d? | 355d | start no earlier than 2006-10-30 | WG4 |  |  | Stastny Richard | richard.stastny@OEFEG.AT | 0.0.1 | 2-1stDraft |  |
| 80 | 15.2 | STOPPED - Minimum requirements for interoperability of ENUM implementations | milestone | 0d? | 2007-04-30 | 2007-04-30 |  |  | 2006-04-30 | 2007-04-30 | 261d? | 225d | start no earlier than 2007-04-30 | WG4 |  |  | Stastny Richard | richard.stastny@OEFEG.AT | 1.3.1 | TBadoptionofWI | TS 102 172 |
| 81 | 15.3 | Interconnect issues related to Numbering Naming and Addressing (NAR): NAR Interconnect |  | 426d? | 2005-05-13 A | 2006-12-30 | 80% | 85.2d? | 2005-05-13 | 2006-12-30 | 426d? | 311d | finish no earlier than 2006-12-30 | WG4 | 3408h | 2726.4h | Silletta Francesco | Francesco.Silletta@TelecomItalia.It | 0.0.11 | 6-Stable |  |
| 82 | 15.4 | ENUM privacy and Security: ENUM Privacy |  | 852d? | 2004-02-25 A | 2007-05-31 | 70% | 257.6d? | 2004-02-25 | 2006-12-30 | 743d? | 202d | finish no earlier than 2007-05-31 | WG4 | 6816h | 4755.2h | Holmes Anthony | tony.ar.holmes@bt.com | 0.0.3 | 6-Stable | 184 001 |
| 83 | 16 | **Accounting and Charging Rel-2** |  | 250d? | 2006-08-12 A | 2007-07-27 | 48% | 128.91d? | 2007-04-30 | 2007-08-12 | 75d? | 161d |  |  | 2304h | 1116h |  |  |  |  |  |
| 84 | 16.1 | Charging management in Release 2 |  | 186d? | 2006-08-12 A | 2007-04-30 | 75% | 46.5d? | 2007-04-30 | 2007-08-12 | 75d? | 225d | finish no earlier than 2007-04-30 | WG2 | 1488h | 1116h | Seibel Matthias | matthias.seibel@t-com.net | 2.0.2 | 6-Stable | 282 010 |
| 85 | 16.2 | Transfer of Charging information in SIP |  | 102d? | 2007-03-08 | 2007-07-27 |  |  |  |  |  | 161d | start no earlier than 2007-03-08 | WG3 | 816h |  | Huelsemann Martin | Martin.Huelsemann@t-com.net | 0.0.4 | 6-Stable | 183 058 |
| 86 | 17 | **PSTN/ISDN Emulation Sub-system (PES) Rel-2 Improvements** |  | 368d? | 2006-01-01 A | 2007-05-30 | 30% | 257.6d? | 2006-01-01 | 2007-05-30 | 368d? | 203d |  |  | 2944h | 883.2h |  |  |  |  |  |
| 87 | 17.1 | IMS-based PSTN/ISDN Emulation Sub-system (PES): Functional architecture |  | 368d? | 2006-01-01 A | 2007-05-30 | 30% | 257.6d? | 2006-01-01 | 2007-05-30 | 368d? | 203d | finish no earlier than 2007-05-30 | WG2 | 2944h | 883.2h | Kotar Peter | P.Kotar@alcatel-lucent.de |  | 1-Start | 182 012 |
| 88 | 18 | **QoS and Overload Control Rel-2** |  | 262d? | 2006-05-30 A | 2007-05-30 | 62% | 98.34d? | 2006-05-30 | 2007-07-27 | 304d? | 203d |  |  | 6280h | 3922.8h |  |  |  |  |  |
| 89 | 18.1 | **QoS Rel-2** |  | 218d? | 2006-07-30 A | 2007-05-30 | 87% | 28.02d? | 2006-07-30 | 2007-05-30 | 218d? | 203d |  |  | 2872h | 2502.8h |  |  |  |  |  |
| 90 | 18.1.1 | Requirements for QoS in a NGN |  | 218d? | 2006-07-30 A | 2007-05-30 | 95% | 10.9d? | 2006-07-30 | 2007-05-30 | 218d? | 203d | finish no earlier than 2007-05-30 | WG1 | 1744h | 1656.8h | GRITELLA Gianluca | Gianluca.Gritella@TelecomItalia.it | 0.6.1 | 6-Stable | 181 018 |
| 91 | 18.1.2 | Architectures for QoS handling |  | 141d? | 2006-09-15 A | 2007-03-30 | 75% | 35.25d? | 2006-09-15 | 2007-03-30 | 141d? | 246d | finish no earlier than 2007-03-30 | WG2 | 1128h | 846h | Apicella Laura | laura.apicella@telecomitalia.it | 0.0.2 | 2-1st Draft | 182 022 |
| 92 | 18.2 | **Overload and Congestion Control (OCC)** |  | 260d? | 2006-05-30 A | 2007-05-28 | 42% | 151.67d? | 2006-05-30 | 2007-07-27 | 304d? | 205d |  |  | 3408h | 1420h |  |  |  |  |  |
| 93 | 18.2.1 | Requirements for Processing Overload Control |  | 260d? | 2006-05-30 A | 2007-05-28 | 21% | 206.4d? | 2006-05-30 | 2006-08-30 | 67d? | 205d | finish no earlier than 2007-05-28 | WG2 | 2080h | 428.8h | Stewart Nicholas | nick.m.stewart@bt.com | 0.0.5 | 6-Stable | 182 018 |
| 94 | 18.2.2 | OCC Architecture: Part 2: Overload and Congestion control GOCAP |  | 85d? | 2007-01-01 A | 2007-04-27 | 60% | 34d? | 2007-03-30 | 2007-07-27 | 86d? | 226d | start no earlier than 2007-01-01 | WG3 | 680h | 408h | Mart Philip | philip.mart@ericsson.com | 0.0.7 | 6-Stable | ES 283 039-2 |
| 95 | 18.2.3 | OCC Architecture: Part 4: Adaptative Control for the MGC: Gocap MGC |  | 81d? | 2006-12-08 A | 2007-03-31 | 90% | 8.1d? | 2006-12-08 | 2007-03-31 | 81d? | 246d | finish no earlier than 2007-03-31 | WG3 | 648h | 583.2h | Mart Philip | philip.mart@ericsson.com | 2.1.1 | DraftreceiptbyETSISecretariat | ES 283 039-4 |
| 96 | 19 | **NASS Rel-2 Improvements** |  | 278d? | 2006-12-29 A | 2008-01-22 | 36% | 177.95d? | 2007-08-30 | 2007-12-29 | 87d? | 34d |  |  | 5504h | 1980.8h |  |  |  |  |  |
| 97 | 19.1 | NGN Functional Architecture: NGN NASS |  | 175d? | 2006-12-29 A | 2007-08-30 A | 100% |  | 2007-08-30 | 2007-12-29 | 87d? |  | finish no earlier than 2007-08-30 | WG2 | 1400h | 1400h | Brockners Frank | fbrockne@cisco.com | 0.0.5 | 2-1st Draft | 282 004 |
| 98 | 19.2 | NASS - e2 interface based on the DIAMETER protocol |  | 213d? | 2007-03-30 A | 2008-01-22 | 20% | 170.4d? |  |  |  | 34d | start no earlier than 2007-03-30 | WG3 | 1704h | 340.8h | Chatras Bruno | bruno.chatras@orange-ftgroup.com | 2.0.2 | 6-Stable | 283 035 |
| 99 | 19.3 | NASS - a2 interface based on the DIAMETER protocol |  | 150d? | 2007-05-18 A | 2007-12-13 | 10% | 135d? |  |  |  | 62d | finish no earlier than 2007-12-13 | WG3 | 1200h | 120h | Tsou (zou) Tina (ting) | tena@huawei.com | 0.0.1 | 2-1st Draft | 183 059-1 |
| 100 | 19.4 | NASS - a2 interface based on the RADIUS protocol |  | 150d? | 2007-05-18 A | 2007-12-13 | 10% | 135d? |  |  |  | 62d | finish no earlier than 2007-12-13 | WG3 | 1200h | 120h | Tsou (zou) Tina (ting) | tena@huawei.com | 0.0.1 | 2-1st Draft | 183 059-2 |

| ID | WBS | Task | Duration | Start | Finish | Complete | Remaining | Baseline start | Baseline finish | Baseline duration | Total slack | Constraint | Resources | Work | Actual work | Text4 | Text5 | Text13 | Text14 | Text15 |
| --- | --- | --- | --- | --- | --- | --- | --- | --- | --- | --- | --- | --- | --- | --- | --- | --- | --- | --- | --- | --- |
| 101 | 20 | **RACS Rel-2 Improvements** | 355d? | 2006-06-16 A | 2007-10-25 | 60% | 140.73d? | 2006-05-29 | 2007-06-30 | 285d? | 97d |  |  | 5032h | 3037.2h |  |  |  |  |  |
| 102 | 20.1 | Functional Architecture: Subsystem (RACS): RACS | 227d? | 2006-06-16 A | 2007-04-30 | 15% | 192.95d? | 2006-06-16 | 2007-04-30 | 227d? | 225d | finish no earlier than 2007-04-30 | WG2 | 1816h | 272.4h | Gamelas Antonio | AGamelas@PTINOVACAO.PT | 182 019 | 0.3.2 | 6-Stable |
| 103 | 20.2 | H.248 Profile for controlling Border Gateway Functions (BGF) in the Subsystem (RACS): Protocol specification: Ia Interface H.248 | 204d? | 2007-01-15 A | 2007-10-25 A | 100% |  | 2006-10-12 | 2007-06-30 | 187d? |  | finish no earlier than 2007-10-25 | WG3 | 1632h | 1632h | Cutler Wayne | Wayne.Cutler@ericsson.com | 283 018 | 2.0.8 | 6-Stable |
| 104 | 20.3 | Specification of Bearer Control Protocol (BC) | 198d? | 2006-10-26 A | 2007-07-30 | 72% | 56.4d? | 2006-05-29 | 2007-01-30 | 177d? | 160d | finish no earlier than 2007-07-30 | WG3 | 1584h | 1132.8h | Tsou (zou) Tina (ting) | tena@huawei.com | 283 044 | 0.0.7 | 6-Stable |
| 105 | 21 | **Network Management Rel-2** | 728d? | 2005-02-28 A | 2007-12-12 | 47% | 384.06d? | 2005-02-28 | 2007-11-30 | 720d? | 63d |  |  | 18000h | 8504h |  |  |  |  |  |
| 106 | 21.1 | WG8 Specification Guidelines: NGN OSS Guidelines | 320d? | 2006-09-21 A | 2007-12-12 | 25% | 240d? | 2006-09-21 | 2007-11-30 | 312d? | 63d | finish no earlier than 2007-12-12 | WG8 | 2560h | 640h | Abramowski Ute | ute.abramowski@t-systems.com | 188 007 | 0.0.4 | 6-Stable |
| 107 | 21.2 | **NGN Management Network Resource Model (NRM)** | 663d? | 2005-02-28 A | 2007-09-12 | 67% | 215.8d? | 2005-02-28 | 2007-03-30 | 545d? | 128d |  |  | 10704h | 7220h |  |  |  |  |  |
| 108 | 21.2.1 | NRM Part 1: Requirements | 465d? | 2005-02-28 A | 2006-12-08 A | 100% |  | 2005-02-28 | 2006-12-08 | 465d? |  | finish no earlier than 2006-12-08 | WG8 | 3720h | 3720h | Caryer Geoffrey | geoff@tmconsult.co.uk | TS 188 005-1 | 1.1.1 | DraftreceiptbyETSISecretariat |
| 109 | 21.2.2 | NRM Part 2: Information service | 625d? | 2005-02-28 A | 2007-07-20 | 70% | 187.5d? | 2005-02-28 | 2007-03-30 | 545d? | 166d | finish no earlier than 2007-07-20 | WG8 | 5000h | 3500h | Caryer Geoffrey | geoff@tmconsult.co.uk | TS 188 005-2 | 0.0.5 | 6-Stable |
| 110 | 21.2.3 | NRM Part 3: Solution set | 248d? | 2006-10-02 | 2007-09-12 |  |  | 2006-10-02 | 2007-02-28 | 108d? | 128d | finish no earlier than 2007-09-12 | WG8 | 1984h |  | Caryer Geoffrey | geoff@tmconsult.co.uk | TS 188 005-3 |  | 1-Start |
| 111 | 21.3 | **Management Information Model (MIM)** | 389d? | 2006-06-16 A | 2007-12-12 | 14% | 336.1d? | 2006-06-16 | 2007-07-30 | 292d? | 63d |  |  | 4736h | 644h |  |  |  |  |  |
| 112 | 21.3.1 | MIM Part 1: Requirements: Management Information Model Requirements. | 322d? | 2006-06-16 A | 2007-09-10 | 25% | 241.5d? | 2006-06-16 | 2007-01-30 | 163d? | 130d | finish no earlier than 2007-09-10 | WG8 | 2576h | 644h | Fodil Idir | idir.fodil@orange-ftgroup.com | TS 188 006-1 | 0.0.4 | 6-Stable |
| 113 | 21.3.2 | MIM Part 2: Information service: Management Information service | 270d? | 2006-11-30 | 2007-12-12 |  |  | 2006-11-30 | 2007-07-30 | 173d? | 63d | finish no earlier than 2007-12-12 | WG8 | 2160h |  | Fodil Idir | idir.fodil@orange-ftgroup.com | TS 188 006-2 |  | 1-Start |
| 114 | 22 | **Subscription Management (SM)** | 341d? | 2006-06-30 A | 2007-10-19 | 48% | 177.56d? | 2006-06-30 | 2007-07-30 | 282d? | 101d |  |  | 5800h | 2780h |  |  |  |  |  |
| 115 | 22.1 | SM Part 1: Requirements | 194d? | 2006-06-30 A | 2007-03-28 A | 100% |  | 2006-06-30 | 2007-01-30 | 153d? |  | finish no earlier than 2007-03-28 | WG8 | 1552h | 1552h | Fodil Idir | idir.fodil@orange-ftgroup.com | TS 188 002-1 | 1.1.1 | DraftreceiptbyETSISecretariat |
| 116 | 22.2 | SM Part 2: Information Model | 211d? | 2006-09-29 A | 2007-07-20 | 50% | 105.5d? | 2006-09-29 | 2007-03-30 | 131d? | 166d | finish no earlier than 2007-07-20 | WG8 | 1688h | 844h | Fodil Idir | idir.fodil@orange-ftgroup.com | TS 188 002-2 | 0.0.5 | 2-1stDraft |
| 117 | 22.3 | SM Part 3: Functional Architecture | 320d? | 2006-07-30 A | 2007-10-19 | 15% | 272d? | 2006-07-30 | 2007-07-30 | 261d? | 101d | finish no earlier than 2007-10-19 | WG8 | 2560h | 384h | Fodil Idir | idir.fodil@orange-ftgroup.com | TS 188 002-3 | 0.0.1 | 2-1stDraft |
| 118 | 23 | **NGN Security Rel-2** | 391d? | 2006-06-16 A | 2007-12-16 | 33% | 262.29d? | 2006-06-16 | 2007-07-05 | 275d? | 61d |  |  | 10552h | 3473.6h |  |  |  |  |  |
| 119 | 23.1 | NGN Security; Feasibility study of prevention of unsolicited communication in the NGN | 249d? | 2006-12-30 A | 2007-12-13 | 30% | 174.3d? | 2006-12-30 | 2007-06-29 | 130d? | 62d | finish no earlier than 2007-12-13 | WG7 | 1992h | 597.6h | Ewald Thilo | thilo.ewald@netlab.nec.de |  | 0.0.6 | 6-Stable |
| 120 | 23.2 | NGN Security Countermeasures: Stage 2 | 355d? | 2006-06-16 A | 2007-10-25 | 35% | 230.75d? | 2006-06-16 | 2007-05-30 | 249d? | 97d | finish no earlier than 2007-10-25 | WG7 | 2840h | 994h | Matti Enquist | matti.enqvist@ericsson.com | 187 006 | 0.0.5 | 6-Stable |
| 121 | 23.3 | Feasibility study on Media Security in TISPAN NGN | 315d? | 2006-09-30 A | 2007-12-16 | 35% | 204.75d? | 2006-10-20 | 2007-05-30 | 159d? | 61d | finish no earlier than 2007-12-16 | WG7 | 2520h | 882h | He Dony | donyhe@huawei.com | 187 007 | 0.0.4 | 6-Stable |
| 122 | 23.4 | NAT traversal feasibility study report | 225d? | 2006-12-15 A | 2007-10-25 | 40% | 135d? | 2006-10-20 | 2007-07-05 | 185d? | 97d | finish no earlier than 2007-10-25 | WG7 | 1800h | 720h | Duault Maurice | mduault@cisco.com | 187 008 | 0.0.7 | 6-Stable |
| 123 | 23.5 | NGN SECurity (SEC) Requirements - Release 2 | 175d? | 2007-02-28 A | 2007-10-30 | 20% | 140d? |  |  |  | 94d | start no earlier than 2007-02-28 | WG7 | 1400h | 280h | Enqvist Matti | matti.enqvist@ericsson.com | 187 001 | 2.0.1 | 6-Stable |
| 124 | 24 | **Security Miscellaneous** | 215d? | 2007-02-19 A | 2007-12-14 | 11% | 190.59d? | 2005-06-30 | 2007-07-30 | 543d? | 61d |  |  | 6448h | 732h |  |  |  |  |  |
| 125 | 24.1 | NGN Security Requirements Rel2 | 175d? | 2007-02-28 | 2007-10-30 |  |  |  |  |  | 94d | start no earlier than 2007-02-28 | WG7 | 1400h |  | Enqvist Matti | matti.enqvist@ericsson.com | 187 001 | 2.0.2 | 6-Stable |
| 126 | 24.2 | Check Rel - NGN Security; Report on security of identity in the NGN; | 151d? | 2007-05-18 A | 2007-12-14 | 25% | 113.25d? |  |  |  | 61d | start no earlier than 2007-05-18 | WG7 | 1208h | 302h | Cadzow Scott | scott@cadzow.com |  | 0.0.2 | 6-Stable |
| 127 | 24.3 | Check Rel - Method for application of ISO 15408-2 requirements in NGN; | 186d? | 2007-03-30 A | 2007-12-14 | 10% | 167.4d? |  |  |  | 61d | start no earlier than 2007-03-30 | WG7 | 1488h | 148.8h | Cadzow Scott | scott@cadzow.com |  | 0.0.1 | 2-1st Draft |
| 128 | 24.4 | Security Architecture; Release 2; | 179d? | 2007-02-19 A | 2007-10-25 | 10% | 161.1d? |  |  |  | 97d | finish no earlier than 2007-10-25 | WG7 | 1432h | 143.2h | Blanchard Colin | colin.blanchard@bt.com | 187 003 | 0.0.1 | TOC agreed |
| 129 | 24.5 | Threat, Vulnerability and Risk Analysis - Release 2; | 115d? | 2007-05-18 A | 2007-10-25 | 15% | 97.75d? |  |  |  | 97d | start no earlier than 2007-05-18 | WG7 | 920h | 138h | Cadzow Scott | scott@cadzow.com | 187 002 | 2.0.0 | 2-1st Draft |

| ID | WBS | Task | Duration | Start | Finish | Complete | Remaining | Baseline start | Baseline finish | Baseline duration | Total slack | Constraint | Resources | Work | Actual work | Text4 | Text5 | Text13 | Text14 | Text15 |
| --- | --- | --- | --- | --- | --- | --- | --- | --- | --- | --- | --- | --- | --- | --- | --- | --- | --- | --- | --- | --- |
| 130 | 25 | **Interworking** | 615d? | 2005-10-30 A | 2008-03-07 | 48% | 322.2d? |  |  |  | 1d |  |  | 8704h | 4144h |  |  |  |  |  |
| 131 | 25.1 | Solution for REFER interworking problems | 231d? | 2006-10-20 A | 2007-09-07 A | 100% |  | 2006-10-20 | 2007-05-30 | 159d? |  | finish no earlier than 2007-09-07 | WG3 | 1848h | 1848h | Huelsemann Martin | Martin.Huelsemann@t-com.net | 183 052 | 0.0.6 | 6-Stable |
| 132 | 25.2 | ISDN- DSS1/SIP inter-working | 127d? | 2007-02-02 A | 2007-07-30 | 20% | 101.6d? |  |  |  | 160d | finish no earlier than 2007-07-30 | WG3 | 1016h | 203.2h | Brand Martin | Martin.Brand@telekom.at | 183 036 | 0.2.0 | 6-Stable |
| 133 | 25.3 | Endorsement of the SIP-ISUP Interworking between IMS and CS [3GPP TS 29.163 (Rel 7), modified] | 211d? | 2007-05-18 | 2008-03-07 |  |  |  |  |  | 1d | start no earlier than 2007-05-18 | WG3 | 1688h |  | Jesske Roland | r.jesske@t-com.net | 283 027 |  | 0-New |
| 134 | 25.4 | SDP Interworking between SIP/SDP and H.248/SDP | 519d? | 2005-10-30 A | 2007-10-25 | 50% | 257.4d? | 2005-10-30 | 2007-01-30 | 327d? | 97d | finish no earlier than 2007-10-25 | WG3 | 4152h | 2092.8h | Waitzmann Carsten | cwaitzmann@alcatel-lucent.de | 183 046 | 0.0.13 | 6-Stable |
| 135 | 26 | **Other Rel-2 aspects** | 610d? | 2005-10-28 A | 2008-02-28 | 40% | 364.14d? | 2005-10-28 | 2007-10-30 | 523d? | 7d |  |  | 22888h | 9224.8h |  |  |  |  |  |
| 136 | 26.1 | Register of assigned protocol numbers and names: Registration | 71d? | 2006-12-15 A | 2007-03-23 A | 100% |  | 2006-10-30 | 2007-05-30 | 153d? |  | finish no earlier than 2007-03-23 | WG3 | 568h | 568h | Mulligan Ultan | ultan.mulligan@etsi.org | 183 050 | 1.1.1 | 12 |
| 137 | 26.2 | H.248 Non-call related procedures and management system interaction: Management of MGC and H.248 | 369d? | 2006-01-01 A | 2007-05-31 | 90% | 36.9d? | 2006-01-01 | 2007-01-30 | 282d? | 202d | finish no earlier than 2007-05-31 | WG3 | 2952h | 2656.8h | Cutler Wayne | Wayne.Cutler@ericsson.com | 183 025 | 2.0.0 | 7-WGapp |
| 138 | 26.3 | H.248 Profile for controlling Trunking Media Gateways (TMG): Endorsement of 3GPP TS 29.332 Rel 7 modified: H.248 TMG. | 459d? | 2006-01-21 A | 2007-10-25 | 33% | 309.4d? | 2006-10-12 | 2007-06-30 | 187d? | 97d | finish no earlier than 2007-10-25 | WG3 | 3672h | 1196.8h | Kauntola Seppo | seppo.kauntola@nsn.com | 283 049 | 2.0.0 | 6-Stable |
| 139 | 26.4 | PES: H.248 Profile for controlling Access and Residential Gateways | 459d? | 2006-01-21 A | 2007-10-25 | 20% | 367.2d? | 2007-10-12 | 2007-10-12 | 1d? | 97d | finish no earlier than 2007-10-25 | WG3 | 3672h | 734.4h | Waitzmann Carsten | cwaitzmann@alcatel-lucent.de | 283 002 | 2.0.6 | 6-Stable |
| 140 | 26.5 | Requirements for originating and terminating party multimedia information presentation and restriction | 151d? | 2006-10-20 A | 2007-05-18 | 95% | 7.9d? | 2006-10-20 | 2007-03-23 | 111d? | 211d | finish no earlier than 2007-05-18 | WG1 | 1208h | 1144.8h | Le Mercier Claudine | claudine.lemercier@orange-ftgroup.com | 181 015 | 2.0.0 | 6-Stable |
| 141 | 26.6 | Endorsement ot 3GPP TS 29.328 and 29.329 (Release 6) | 371d? | 2005-10-28 A | 2007-03-30 | 80% | 74.2d? | 2005-10-28 | 2007-03-30 | 371d? | 246d | finish no earlier than 2007-03-30 | WG3 | 2968h | 2374.4h | Cuda Alberto | alberto.cuda@tilab.com | TS 183 036 | 0.0.2 | 6-Stable |
| 142 | 26.7 | Support of Overlap sending v2 in a IMS NGN Release 2 | 130d? | 2007-01-30 A | 2007-07-30 | 20% | 104d? |  |  |  | 160d | finish no earlier than 2007-07-30 | WG3 | 1040h | 208h | Norreys Steve | steve.norreys@bt.com | 183 056 | 0.0.2 | 6-Stable |
| 143 | 26.8 | Feasibility study on Out-of-band DTMF transport | 127d? | 2007-02-02 A | 2007-07-30 | 20% | 101.6d? |  |  |  | 160d | finish no earlier than 2007-07-30 | WG3 | 1016h | 203.2h | Chatras Bruno | bruno.chatras@orange-ftgroup.com | 183 057 | 0.0.1 | 6-Stable |
| 144 | 26.9 | Re Reference Point Protocol Specification | 173d? | 2007-05-23 A | 2008-01-20 | 10% | 155.7d? |  |  |  | 36d | finish no earlier than 2008-01-20 | WG3 | 1384h | 138.4h | CRISTALLO Geoffrey | geoffrey.cristallo@alcatel-lucent.be | 183 060 | 0.1.0 | 2-1st Draft |
| 145 | 26.10 | Network Access xDSL and WLAN Access Networks; Interface Protocol Definitions | 150d? | 2007-05-18 | 2007-12-13 |  |  |  |  |  | 62d | finish no earlier than 2007-12-13 | WG3 | 1200h |  | Chatras Bruno | bruno.chatras@orange-ftgroup.com | 183 019 | 2.0.1 | 0-New |
| 146 | 26.11 | NGN Release 2 Lawful Interception Stage 2 definition | 205d? | 2007-05-18 | 2008-02-28 |  |  |  |  |  | 7d | start no earlier than 2007-05-18 | WG3 | 1640h |  | Cadzow Scott | scott@cadzow.com | 187 005 |  | 0-New |
| 147 | 26.12 | Stage 3 of Ri' Reference Point | 196d? | 2007-05-18 | 2008-02-15 |  |  |  |  |  | 16d | finish no earlier than 2008-02-15 | WG3 | 1568h |  | Elabed Dina | dina.elabed@orange-ftgroup.com |  |  | 0-New |
| 148 | 27 | **Testing Rel-2** | 773d? | 2004-06-30 A | 2007-06-15 | 56% | 338.7d? | 2004-06-30 | 2006-12-30 | 653d? | 191d |  |  | 9896h | 5560h |  |  |  |  |  |
| 149 | 27.1 | Network Integration testing between H.323, ISDN and PSTN: Part 1: Test Suite Structure and Test purposes (TSS&TP): NIT H.323 | 653d? | 2004-06-30 A | 2006-12-30 | 80% | 130.6d? | 2004-06-30 | 2006-12-30 | 653d? | 311d | finish no earlier than 2006-12-30 | WG6 | 5224h | 4179.2h | Brand Martin | Martin.Brand@telekom.at | TS 102 169-1 | 0.0.5 | 6-Stable |
| 150 | 27.2 | Network Performance objectives tests for IP-based Voice services: QoS performance test | 183d? | 2005-09-16 A | 2006-05-30 | 80% | 36.6d? | 2005-09-16 | 2006-05-30 | 183d? | 464d | start no earlier than 2006-06-01 | WG6 | 1464h | 1171.2h | Brand Martin | Martin.Brand@telekom.at | TS 102 547 | 0.1.6 | 6-Stable |
| 151 | 27.3 | Conformance test specification for interworking between SIP and ISDN/PSTN network signaling protocols: Part 2: Test Suite Structure (TSS) and Test Purposes (TP): SIP-ISDN/PSTN TSS&TP | 131d? | 2005-12-30 A | 2006-06-30 | 20% | 104.8d? | 2005-12-30 | 2006-06-30 | 131d? | 441d | finish no earlier than 2006-06-30 | WG6 | 1048h | 209.6h | Brand Martin | Martin.Brand@telekom.at |  | 0.0.1 | 2-1stDraft |
| 152 | 27.4 | **Explicit Communication Transfer (ECT) Testing** | 135d? | 2006-12-11 | 2007-06-15 |  |  |  |  |  | 191d |  |  | 2160h |  | Gerhard Ott | gerhard.ott@t-com.net |  |  |  |
| 153 | 27.4.1 | ECTtesting Part 1: PICS | 135d? | 2006-12-11 | 2007-06-15 |  |  |  |  |  | 191d | finish no earlier than 2007-06-15 | WG6 | 1080h |  | Gerhard Ott | gerhard.ott@t-com.net |  |  |  |
| 154 | 27.4.2 | ECT testing Part 2: Test Suite Structure and Test Purposes (TSS&TP) | 135d? | 2006-12-11 | 2007-06-15 |  |  |  |  |  | 191d | finish no earlier than 2007-06-15 | WG6 | 1080h |  | Gerhard Ott | gerhard.ott@t-com.net |  |  |  |
